# 050307 Work Program

Schedule from MS Project, 2005-02-01 to 2005-11-14, 12 hours a day, A marks actual dates.
CMT

## Calendars

- Standard: Mon-Fri 07:00-19:00; Sat-Sun off. Exceptions (off unless hours are given): 2005-03-25, 2005-03-28.

## Resources

| Resource |
| --- |
| Allan McGill |
| Will Godsall |
| Colin Carter |
| Rob Johnston |
| Mike Phelan |
| Kim Denwer |
| Drilling Contractor |
| Zonge |

## Schedule

| ID | WBS | Task | Duration | Start | Finish | Predecessors | Complete | Remaining | Total slack | Free slack | Constraint | Resources | Work | Actual work |
| --- | --- | --- | --- | --- | --- | --- | --- | --- | --- | --- | --- | --- | --- | --- |
| 1 | 1 | **Prince Lyell** | 33d | 2005-02-24 A | 2005-04-13 |  | 16% | 27.63d | 153d |  |  |  | 454h | 84h |
| 2 | 1.1 | Establish cut off date for results | 1d | 2005-03-07 | 2005-03-07 |  |  |  | 153d | 0d | start no earlier than 2005-03-07 | Allan McGill | 12h |  |
| 3 | 1.2 | Load ssays to DB | 1d | 2005-03-08 | 2005-03-08 | 2 |  |  | 153d | 0d |  | Allan McGill | 12h |  |
| 4 | 1.3 | Update Oct (and Ily) surfaces | 3d | 2005-02-24 A | 2005-02-26 A |  | 100% |  |  |  | start no earlier than 2005-02-24 | Colin Carter | 36h | 36h |
| 5 | 1.4 | Make an unconstrained solid | 1d | 2005-02-28 A | 2005-02-28 A | 4 | 100% |  |  |  |  | Allan McGill | 12h | 12h |
| 6 | 1.5 | Intersect solid and Oct dtm | 1d | 2005-03-01 A | 2005-03-01 A | 5 | 100% |  |  |  |  | Allan McGill | 12h | 12h |
| 7 | 1.6 | Flag drillholes | 1d | 2005-03-09 | 2005-03-09 | 6, 3 |  |  | 153d | 0d |  | Allan McGill | 12h |  |
| 8 | 1.7 | Make model - assign attributes - estimate blocks | 2d | 2005-02-28 A | 2005-03-01 A |  | 100% |  |  |  | start no earlier than 2005-02-28 | Allan McGill | 24h | 24h |
| 9 | 1.8 | Assays (Cu/Au, SG, ±) & Geostats | 3d | 2005-03-10 | 2005-03-14 | 7 |  |  | 153d | 0d |  | Allan McGill | 36h |  |
| 10 | 1.9 | Interpolate Block Model | 4d | 2005-03-15 | 2005-03-18 | 9, 8 |  |  | 153d | 0d |  | Allan McGill | 48h |  |
| 11 | 1.10 | Validate | 1d | 2005-03-21 | 2005-03-21 | 10 |  |  | 153d | 0d |  | Allan McGill [50%]; Will Godsall [50%] | 10h |  |
| 12 | 1.11 | Tabulate Mineral Resources | 3d | 2005-03-22 | 2005-03-24 | 11 |  |  | 153d | 0d |  | Will Godsall | 36h |  |
| 13 | 1.12 | Mineral resource report | 5d | 2005-03-29 | 2005-04-04 | 12 |  |  | 160d |  |  | Allan McGill | 60h |  |
| 14 | 1.13 | Ore reserve estimation | 3d | 2005-03-29 | 2005-03-31 | 12 |  |  | 153d | 0d |  | Will Godsall | 36h |  |
| 15 | 1.14 | Ore reserve report | 5d | 2005-04-01 | 2005-04-07 | 14 |  |  | 153d | 0d |  | Rob Johnston [50%]; Will Godsall [50%] | 60h |  |
| 16 | 1.15 | Review and presentation | 4d | 2005-04-08 | 2005-04-13 | 15 |  |  | 153d |  |  | Rob Johnston [50%]; Will Godsall [50%] | 48h |  |
| 17 | 1.16 | Surpac Course | 5d | 2005-03-07 | 2005-03-11 |  |  |  | 14d |  | start no earlier than 2005-03-07 |  |  |  |
| 19 | 2 | **Surface Exploration** | 10d | 2005-02-14 A | 2005-02-25 A |  | 100% |  |  |  |  |  |  |  |
| 20 | 2.1 | Program Write-up & submission to MRT | 10d | 2005-02-14 A | 2005-02-25 A |  | 100% |  |  |  | finish no earlier than 2005-02-25 |  |  |  |
| 22 | 3 | **Copper Clays** | 45d | 2005-02-01 A | 2005-04-06 |  | 31% | 30.94d | 155d |  |  |  | 288h | 90h |
| 23 | 3.1 | Data collation | 2d | 2005-02-01 A | 2005-02-02 A |  | 100% |  |  |  |  | Colin Carter | 24h | 24h |
| 24 | 3.2 | Data entry | 2d | 2005-02-09 A | 2005-02-10 A | 23 | 100% |  |  |  |  | Colin Carter | 24h | 24h |
| 25 | 3.3 | Data validation | 2d | 2005-02-11 A | 2005-02-12 A | 24 | 100% |  |  |  |  | Colin Carter | 24h | 24h |
| 26 | 3.4 | Wireframes | 3d | 2005-02-27 A | 2005-03-01 | 25, 4 | 50% | 1.5d | 164d | 0d |  | Colin Carter | 36h | 18h |
| 27 | 3.5 | Flag drillholes | 1d | 2005-03-02 | 2005-03-02 | 26 |  |  | 164d | 7d |  | Colin Carter | 12h |  |
| 28 | 3.6 | Make model - assign attributes - estimate blocks | 6d | 2005-03-12 | 2005-03-23 | 27 |  |  | 153d | 0d |  | Colin Carter | 72h |  |
| 29 | 3.7 | Validate | 3d | 2005-03-24 | 2005-03-26 | 28 |  |  | 157d | 0d |  | Colin Carter | 36h |  |
| 30 | 3.8 | Report | 5d | 2005-03-27 | 2005-04-06 | 29 |  |  | 155d |  |  | Colin Carter | 60h |  |

| ID | WBS | Task | Type | Duration | Start | Finish | Predecessors | Complete | Remaining | Total slack | Free slack | Constraint | Resources | Work |
| --- | --- | --- | --- | --- | --- | --- | --- | --- | --- | --- | --- | --- | --- | --- |
| 32 | 4 | **ML - Queen Lyell** |  | 94d | 2005-02-28 A | 2005-07-11 |  | 5% | 89.57d | 90d |  |  |  | 480h |
| 33 | 4.1 | Evaluation |  | 3d | 2005-03-16 | 2005-03-18 |  |  |  | 16d | 0d | start no earlier than 2005-03-16 |  |  |
| 34 | 4.2 | Target Generation |  | 2d | 2005-03-21 | 2005-03-22 | 33 |  |  | 16d |  |  |  |  |
| 35 | 4.3 | Track Clearing |  | 7d | 2005-03-07 | 2005-03-15 |  |  |  | 21d |  | start no earlier than 2005-03-07 |  |  |
| 36 | 4.4 | Drill Tender |  | 33d | 2005-02-28 A | 2005-04-15 |  | 15% | 28d | 0d |  | finish no earlier than 2005-04-15 |  |  |
| 37 | 4.5 | Drilling |  | 40d | 2005-04-18 | 2005-06-10 | 36, 35, 34 |  |  | 0d |  | finish no earlier than 2005-04-18 | Drilling Contractor | 480h |
| 38 | 4.6 | Model |  | 10d | 2005-06-13 | 2005-06-24 | 37 |  |  | 90d | 0d |  |  |  |
| 39 | 4.7 | Report |  | 10d | 2005-06-27 | 2005-07-08 | 38 |  |  | 90d |  |  |  |  |
| 40 | 4.8 | Review |  | 1d | 2005-07-11 | 2005-07-11 | 39 |  |  | 90d |  |  |  |  |
| 42 | 5 | **Chamounix Zinc** |  | 119d | 2005-03-07 | 2005-08-22 |  |  |  | 31d |  |  |  | 624h |
| 43 | 5.1 | Remodel |  | 14d | 2005-03-07 | 2005-03-24 |  |  |  | 34d | 0d | start no earlier than 2005-03-07 |  |  |
| 44 | 5.2 | PIMA/Geochemistry |  | 14d | 2005-03-29 | 2005-04-15 | 43, 45 |  |  | 34d | 7d |  | Kim Denwer | 168h |
| 45 | 5.3 | Lines |  | 5d | 2005-03-18 | 2005-03-24 | 69 |  |  | 22d | 0d |  | Mike Phelan | 60h |
| 46 | 5.4 | Geophysics |  | 3d | 2005-04-22 | 2005-04-26 | 70 |  |  | 22d | 0d |  | Zonge | 36h |
| 47 | 5.5 | Geophysics Interp & Report |  | 5d | 2005-04-27 | 2005-05-03 | 46 |  |  | 22d | 0d |  |  |  |
| 48 | 5.6 | Review | milestone | 1d | 2005-05-04 | 2005-05-04 | 47, 44 |  |  | 22d | 0d |  |  |  |
| 49 | 5.7 | Target Generation |  | 5d | 2005-05-05 | 2005-05-11 | 48, 47 |  |  | 22d |  |  |  |  |
| 50 | 5.8 | Drill |  | 30d | 2005-06-13 | 2005-07-22 | 37, 49 |  |  | 0d |  |  | Drilling Contractor | 360h |
| 51 | 5.9 | Model |  | 10d | 2005-07-25 | 2005-08-05 | 50 |  |  | 61d | 0d |  |  |  |
| 52 | 5.10 | Report |  | 10d | 2005-08-08 | 2005-08-19 | 51 |  |  | 61d |  |  |  |  |
| 53 | 5.11 | Review | milestone | 1d | 2005-08-22 | 2005-08-22 | 52 |  |  | 60d |  |  |  |  |
| 55 | 6 | **Burbury Volcanics** |  | 135d | 2005-03-29 | 2005-10-03 |  |  |  | 22d |  |  |  | 756h |
| 56 | 6.1 | Gridding |  | 14d | 2005-03-29 | 2005-04-15 | 45 |  |  | 22d | 0d |  | Mike Phelan | 168h |
| 57 | 6.2 | Mapping |  | 14d | 2005-04-18 | 2005-05-05 | 56 |  |  | 36d | 0d |  |  |  |
| 58 | 6.3 | PIMA/Geochmeistry |  | 14d | 2005-05-06 | 2005-05-25 | 44, 56, 57 |  |  | 36d | 0d |  | Kim Denwer | 168h |
| 59 | 6.4 | Geophysics |  | 5d | 2005-04-27 | 2005-05-03 | 46 |  |  | 49d | 0d |  | Zonge | 60h |
| 60 | 6.5 | Geophysics Interp & Report |  | 5d | 2005-05-04 | 2005-05-10 | 59 |  |  | 49d | 11d |  |  |  |
| 61 | 6.6 | Review | milestone | 1d | 2005-05-26 | 2005-05-26 | 60, 58 |  |  | 38d | 0d |  |  |  |
| 62 | 6.7 | Target Generation |  | 3d | 2005-05-27 | 2005-05-31 | 58, 61, 60 |  |  | 38d |  |  |  |  |
| 63 | 6.8 | Drill |  | 30d | 2005-07-25 | 2005-09-02 | 50, 62 |  |  | 0d |  |  | Drilling Contractor | 360h |
| 64 | 6.9 | Model |  | 10d | 2005-09-05 | 2005-09-16 | 63 |  |  | 30d | 0d |  |  |  |
| 65 | 6.10 | Report |  | 10d | 2005-09-19 | 2005-09-30 | 64 |  |  | 30d | 0d |  |  |  |
| 66 | 6.11 | Review |  | 1d | 2005-10-03 | 2005-10-03 | 65 |  |  | 30d |  |  |  |  |

| ID | WBS | Task | Type | Duration | Start | Finish | Predecessors | Total slack | Free slack | Constraint | Resources | Work |
| --- | --- | --- | --- | --- | --- | --- | --- | --- | --- | --- | --- | --- |
| 68 | 7 | **Glen Lyell** |  | 174d? | 2005-03-14 | 2005-11-14 |  | 0d |  |  |  | 816h |
| 69 | 7.1 | Lines |  | 4d | 2005-03-14 | 2005-03-17 |  | 22d | 0d | start no earlier than 2005-03-14 | Mike Phelan | 48h |
| 70 | 7.2 | Geophysics |  | 4d | 2005-04-18 | 2005-04-21 | 56, 69 | 22d | 0d |  | Zonge | 48h |
| 71 | 7.3 | Geophysics Interp & Report |  | 5d | 2005-04-22 | 2005-04-28 | 70 | 54d | 0d |  |  |  |
| 72 | 7.4 | Review | milestone | 1d | 2005-04-29 | 2005-04-29 | 71 | 54d | 18d |  |  |  |
| 73 | 7.5 | **PIMA/Geochemistry** |  | 30d | 2005-05-26 | 2005-07-06 | 69, 72 | 36d |  |  |  | 360h |
| 74 | 7.5.1 | Identify Drill holes |  | 5d | 2005-05-26 | 2005-06-01 | 58 | 36d | 0d | start no earlier than 2005-05-02 | Kim Denwer | 60h |
| 75 | 7.5.2 | Relog / PIMA |  | 15d | 2005-06-02 | 2005-06-22 | 74 | 36d | 0d |  | Kim Denwer | 180h |
| 76 | 7.5.3 | Interpret PIMA |  | 10d | 2005-06-23 | 2005-07-06 | 75 | 36d | 0d |  | Kim Denwer | 120h |
| 77 | 7.6 | Review | milestone | 1d | 2005-07-07 | 2005-07-07 | 76 | 36d | 0d |  |  |  |
| 78 | 7.7 | Target generation |  | 5d | 2005-07-08 | 2005-07-14 | 76, 77 | 36d |  |  |  |  |
| 79 | 7.8 | Drill |  | 30d | 2005-09-05 | 2005-10-14 | 78, 63 | 0d |  |  | Drilling Contractor | 360h |
| 80 | 7.9 | Model |  | 10d | 2005-10-17 | 2005-10-28 | 79 | 0d |  |  |  |  |
| 81 | 7.10 | Report |  | 10d | 2005-10-31 | 2005-11-11 | 80 | 0d |  |  |  |  |
| 82 | 7.11 | Review |  | 1d? | 2005-11-14 | 2005-11-14 | 81 | 0d |  |  |  |  |
